# Projektplan mFund envVisio-GI

Schedule from GanttProject, 2020-09-14 to 2022-11-30.

## Calendars

- Project calendar: Mon-Fri working; Sat-Sun off.

## Resources

| Resource |
| --- |
| Fachhochschule Erfurt (FHE) |
| Kreis Lippe (LIP) |
| Stadt Leipzig (L) |
| Vogelsbergkreis (VK) |
| Stadt Dresden (DD) |
| Bundesamt für Kartographie und Geodäsie (BKG) |
| M.O.S.S. GmbH (MOSS) |
| Simplex4Data GmbH (S4D) |
| HRD Consulting (HRD) |
| Scopeland Technology GmbH (SCL) |

## Schedule

| ID | WBS | Task | Type | Duration | Start | Finish | Predecessors | Resources |
| --- | --- | --- | --- | --- | --- | --- | --- | --- |
| 1 | 1 | **Projektkoordination** |  | 191d | 2020-09-15 | 2021-06-08 |  |  |
| 2 | 1.1 | Regelmäßige Treffen der AG Anwendungsfall organisieren |  | 26d | 2020-09-15 | 2020-10-20 |  | Bundesamt für Kartographie und Geodäsie (BKG) |
| 3 | 1.2 | AG Anwendungsfall Treffen Termin | milestone | 0d | 2020-10-21 | 2020-10-21 | 2 | Fachhochschule Erfurt (FHE); Kreis Lippe (LIP); Stadt Leipzig (L); Vogelsbergkreis (VK); Stadt Dresden (DD); Bundesamt für Kartographie und Geodäsie (BKG); M.O.S.S. GmbH (MOSS); Simplex4Data GmbH (S4D); Scopeland Technology GmbH (SCL) |
| 4 | 1.3 | Gesamtprojekttreffen Terminfindung |  | 21d | 2020-12-01 | 2020-12-29 |  |  |
| 5 | 1.4 | Lizenzschließung mit DLZ zur Datennutzung |  | 16d | 2021-01-04 | 2021-01-25 |  |  |
| 6 | 1.5 | **Unterarbeitspaketkoordination** |  | 135d | 2020-12-02 | 2021-06-08 |  |  |
| 7 | 1.5.1 | Gespräche zu AP2 (Datenimport) |  | 6d | 2020-12-02 | 2020-12-09 |  | Kreis Lippe (LIP); Stadt Leipzig (L); Vogelsbergkreis (VK); Stadt Dresden (DD); Bundesamt für Kartographie und Geodäsie (BKG); Simplex4Data GmbH (S4D); Scopeland Technology GmbH (SCL) |
| 8 | 1.5.2 | Gespräche zu AP5 organisieren (Services und APIs) |  | 6d | 2021-03-08 | 2021-03-15 |  | Bundesamt für Kartographie und Geodäsie (BKG); M.O.S.S. GmbH (MOSS) |
| 9 | 1.5.3 | Nicht Haupt-AP Aufgaben koordiniert | milestone | 0d | 2021-03-16 | 2021-03-16 | 7, 8 | Bundesamt für Kartographie und Geodäsie (BKG) |
| 10 | 1.5.4 | Gespräch zu 7.1 (Konzeption und Spezifikation) |  | 6d | 2020-12-18 | 2020-12-25 |  | Fachhochschule Erfurt (FHE); Kreis Lippe (LIP); Stadt Leipzig (L); Vogelsbergkreis (VK); Stadt Dresden (DD); Bundesamt für Kartographie und Geodäsie (BKG) |
| 11 | 1.5.5 | Gespräch zu 7.4 (Spezifikation des Datenmanagments) |  | 7d | 2020-12-25 | 2021-01-04 |  | Kreis Lippe (LIP); Stadt Leipzig (L); Vogelsbergkreis (VK); Stadt Dresden (DD); Bundesamt für Kartographie und Geodäsie (BKG); M.O.S.S. GmbH (MOSS); Simplex4Data GmbH (S4D) |
| 12 | 1.5.6 | Gespräch zu 7.5 (Implementierung von Anwendungsszenarien) |  | 6d | 2021-06-01 | 2021-06-08 |  | Bundesamt für Kartographie und Geodäsie (BKG); Scopeland Technology GmbH (SCL) |
| 13 | 2 | **Berichtspflichten** |  | 432d | 2021-04-05 | 2022-11-29 |  |  |
| 14 | 2.1 | Zwischenbericht I |  | 19d | 2021-04-05 | 2021-04-29 |  |  |
| 15 | 2.2 | Zwischenbericht I eingereicht | milestone | 0d | 2021-04-30 | 2021-04-30 | 14 |  |
| 16 | 2.3 | Zwischenbericht II |  | 19d | 2022-04-04 | 2022-04-28 |  |  |
| 17 | 2.4 | Zwischenbericht II eingereicht | milestone | 0d | 2022-04-29 | 2022-04-29 | 16 |  |
| 18 | 2.5 | Schlussbericht |  | 17d | 2022-11-07 | 2022-11-29 |  |  |
| 19 | 2.6 | Schlussbericht eingereicht | milestone | 0d | 2022-11-30 | 2022-11-30 | 18 |  |
| 20 | 3 | **AP7 (Anwendungsfall Klima und Mobilität)** |  | 445d | 2020-09-15 | 2022-05-30 |  |  |
| 21 | 3.1 | Präsentation über GDI Dokumente & Anforderungen |  | 1d | 2020-09-21 | 2020-09-21 |  | Bundesamt für Kartographie und Geodäsie (BKG) |
| 22 | 3.2 | Relevante GDI Dokumente den Projektpartnern bekannt | milestone | 0d | 2020-09-22 | 2020-09-22 | 21 |  |
| 23 | 3.3 | Erste Eruierungen der Anforderungen Anwendungsfall Klima&Mobilität |  | 26d | 2020-09-15 | 2020-10-20 |  |  |
| 24 | 3.4 | Bereich im GDI-DE Wiki zur Kommunikation und Organisation erstellt | milestone | 0d | 2020-10-20 | 2020-10-20 |  | Bundesamt für Kartographie und Geodäsie (BKG) |
| 25 | 3.5 | Dokumentation des Anwendungsfalls (Klima&Mobilität + inhaltlich&funktional) |  | 420d | 2020-10-20 | 2022-05-30 | 24 | Kreis Lippe (LIP); Stadt Leipzig (L); Vogelsbergkreis (VK); Stadt Dresden (DD); Bundesamt für Kartographie und Geodäsie (BKG) |
| 26 | 3.6 | Schärfung der Anforderungen |  | 29d | 2020-10-22 | 2020-12-01 | 23FS+1d | Kreis Lippe (LIP); Stadt Leipzig (L); Vogelsbergkreis (VK); Stadt Dresden (DD) |
| 27 | 3.7 | Ausarbeitung der Anwendungsszenarien |  | 68d | 2020-12-02 | 2021-03-05 | 26 |  |
| 28 | 3.8 | Erste ausgearbeitete Version von Anwendungsfällen der Projektpartner | milestone | 0d | 2021-03-08 | 2021-03-08 | 27 | Kreis Lippe (LIP); Stadt Leipzig (L); Vogelsbergkreis (VK); Stadt Dresden (DD) |
| 29 | 3.9 | Vorformulierung (SMARTer) Szenarien |  | 65d | 2021-03-05 | 2021-06-03 |  | Fachhochschule Erfurt (FHE); Kreis Lippe (LIP); Stadt Leipzig (L); Vogelsbergkreis (VK); Stadt Dresden (DD); Bundesamt für Kartographie und Geodäsie (BKG) |
| 30 | 3.10 | UAP 7.3 (Datenbereitstellung und Visualisierung) |  | 65d | 2021-03-05 | 2021-06-03 |  | Fachhochschule Erfurt (FHE); Kreis Lippe (LIP); Stadt Leipzig (L); Vogelsbergkreis (VK); Stadt Dresden (DD); Bundesamt für Kartographie und Geodäsie (BKG) |
| 31 | 3.11 | SMARTe Ausarbeitung der Anwendungsfälle |  | 24d | 2021-06-04 | 2021-07-07 | 29, 30 |  |
| 32 | 3.12 | Konsolidierte Ausarbeitung der Anwendungsfälle | milestone | 0d | 2021-07-08 | 2021-07-08 | 31 |  |

Notes:
- 2: UAP 1.1 Projektkoordination
- 3: Jeden ersten Dienstag im Monat um 13:00 Uhr. / Infos zu den Teilnehmern im Ressourcentab.
- 4: UAP 1.1 Projektkoordination / Terminfindung für ein Treffen mit allen beteiligten Projektpartnern. / Informationsautasch innerhalb des Projekts zu zäh.
- 5: DLZ benötigt: / - Name des Projektes / - Förderzeitraum bzw. Projektlaufzeit / - Inhalt bzw. Projektziel (für die genannten Punkte kann ggf. ein Link angegeben werden, sofern die verlinkte Webseite die entsprechenden Informationen enthält) / - Vornamen, Namen, Email-Adressen, Telefonnummern und Adressen von Ansprechpartnern für Vertragliches, Technisches und Bestellungen (hier ist es unproblematisch, wenn einen Person mehrere Rollen übernimmt, was intern natürlich vorher seitens der Projektverantwortlichen geklärt werden muss; zumindest ein Ansprechpartner für Vertragliches muss genannt werden)
- 7: Terminfindung und anschließende Klärung welche Aufgaben das BKG bei / UAP 2.1 (Datenmapping und Modellanpassungen) und / UAP 2.2 (Ausführen der Datenimporte) hat.
- 8: Terminfindung und anschließende Klärung welche Aufgaben das BKG bei / UAP 5.1 (Entwicklung von Web Diensten für den Datenabruf) hat.
- 9: Alle Aufgaben, die nicht in den betreuten Arbeitspaketen 7 & 8 liegen wurden geklärt bzw. abgeschlossen. / --> Die Hauptaufgabe des BKG im AP2 ist die Datenbereitstellung und Klärung unterwelchen Bedingungen gewisse Datensätze zur Verfügung gestellt werden können
- 10: - Erstellen der Sichten für INSPIRE, Berichte, Fachauskünfte und andere Datenbereitstellungen / - Erstellen der Sichten für den Anwendungsfall Klima und Mobilität / Was ist mit den Arbeitsschritten gemeint? / --> Datenbank Views für INSPIRE etc. aus Standards/Richtlinien / --> Datenbank Views für Kommunen anhand der Anwendungsfälle individuell festzulegen
- 11: Terminfindung und anschließende Klärung welche Aufgaben das BKG bei / UAP 7.4 (Spezifikation des Datenmanagments) hat. / -->keine gesonderte Hilfe neben der Koordinierung seitens BKG nötig
- 12: Ist Hilfe seitens des BKGs zu diesem Punkt notwendig?
- 22: Die Projektpartner bekennen sich dazu, Standards und Vorgaben der GDI-DE und INSPIRE einzuhalten. / Relevante Dokumente unter (UAP 7.1): / https://wiki.gdi-de.org/pages/viewpage.action?pageId=757764338
- 23: Erste Inputs: / - Vogelsbergkreis: Harmonisierung von Gebäudedaten / - Leipzig: Prozessoptimierung der Erstellung von Lärmkarten ( Harmonisierung der erforderlichen Daten und Verschneidung/Erzeugung) / - Lippe: inteligentes / Kommunenübergreifendes Verkehrsmanagement ... / - Dresden: noch offen. Bereitstellung von POI Informationen ...
- 24: Offener Bereich im GDI-DE Wiki für alle Projektpartner zugänglich (1 Zugang pro Partner) / Für jedes AP sind bereits eigene Seiten eingerichtet. / Für Datenbedarfe und bereits bekannte Quellen ist unter AP7 eine Tabelle hinterlegt: / https://wiki.gdi-de.org/pages/viewpage.action?pageId=760643802 / hier sollen Bedarfe und bereits bekannte Quellen durch alle Projektpartner ergänzt werden.
- 25: Die Dokumentation findet im GDI-DE Wiki statt und soll sich an der Dokumentation der Fachnetzwerke/technischer Umsetzung orientieren. / Um eine Nachnutzung zu gewährleisten ist eine umfangreiche Dokumentation (auch der Arbeitsschritte) notwendig. Dokumentation muss abstrahierbar sein (7.2).
- 26: Bereitgestellte Strukturen im GDI-DE Wiki sollen genutzt werden um Fälle zu diskutieren und auszuarbeiten.
- 27: Bis zum AG Anwendungsfall Treffen am 05.01.2021 sollen erste konkretere Anwendungsfälle der Projektpartner formuliert sein. / Fall: Zukunftskonzept 2025 Lippe / Fall: Harmonisierung von Gebäudedaten VBK / Fall: Prozessoptimierung Lärmkartierung Leipzig / Fall: ?
- 28: Sobald jeder kommunale Partner einen Anwendungsfall formuliert hat, kann damit begonnen werden, SMARTe Ziele für diese zu stecken. / Status Lippe: Projektabsprachen laufen; Update Mitte Januar / Status Leipzig: Dokumentation läuft / Status Vogelsbergkreis: i.A. / Status Dresden: i.A.
- 29: inkl. Gespräche mit Technik ob realisierbar / S – Spezifisch / M – Messbar / A – Akzeptiert / R – Realistisch / T – Terminierbar
- 30: UAP 7.3: Anforderungen für Datenbereitstellung (gemäß INSPIRE und GDI-DE) sowie an die Visualisierung der Ergebnisse (Technik und Dokumentation) müssen vertieft werden. / Diese werden dokumentiert. / Welche Vorstellungen haben die kommunalen Partner? / Was ist mit der Technik möglich? / --> Gespräche mit Technik und Kommunen
- 32: UAP 7.2

| ID | WBS | Task | Type | Duration | Start | Finish | Predecessors | Resources |
| --- | --- | --- | --- | --- | --- | --- | --- | --- |
| 33 | 4 | **AP8 (Qualitätssicherung und Verwertung)** |  | 263d | 2021-03-08 | 2022-03-09 |  | Bundesamt für Kartographie und Geodäsie (BKG) |
| 34 | 4.1 | Erstellung Qualitätsplan |  | 43d | 2021-03-08 | 2021-05-05 |  |  |
| 35 | 4.2 | Qualitätskonzept erarbeitet | milestone | 0d | 2021-05-06 | 2021-05-06 | 34 |  |
| 36 | 4.3 | Überprüfung der Dokumentation |  | 46d | 2021-05-03 | 2021-07-05 |  |  |
| 37 | 4.4 | Dokumente zur Nachnutzung stehen bereit | milestone | 0d | 2021-07-06 | 2021-07-06 | 36 |  |
| 38 | 4.5 | Überprüfung der Datanbank auf Anforderungen der GDI-DE und Projektpartner |  | 66d | 2021-06-04 | 2021-09-03 | 43, 45 |  |
| 39 | 4.6 | Überprüfung der importierten Daten |  | 63d | 2021-06-07 | 2021-09-01 |  |  |
| 40 | 4.7 | Überprüfung der Anwendung |  | 154d | 2021-07-01 | 2022-02-01 | 46SS |  |
| 41 | 4.8 | Vergleich der finalen Anwendung mit SMART-Zielen |  | 6d | 2022-03-02 | 2022-03-09 | 47 |  |
| 42 | 5 | **Technische Vorgänge** |  | 382d | 2020-09-14 | 2022-03-01 |  |  |
| 43 | 5.1 | AP2 (Datenimport) |  | 189d | 2020-09-14 | 2021-06-03 |  | HRD Consulting (HRD) |
| 44 | 5.2 | Erste Datensichtungen | milestone | 0d | 2021-06-03 | 2021-06-03 |  |  |
| 45 | 5.3 | Zentrale Datenbank mit allen benötigten Daten | milestone | 0d | 2021-06-04 | 2021-06-04 | 43 |  |
| 46 | 5.4 | UAP 7.5 (Implementierung von Anwendungsszenarien) |  | 104d | 2021-06-09 | 2021-11-01 | 12 |  |
| 47 | 5.5 | Anwendungen sind Betriebsbereit | milestone | 0d | 2022-03-02 | 2022-03-02 | 40, 46 |  |
| 48 | 6 | **Hackathon** |  | 64d | 2022-03-01 | 2022-05-27 |  | Fachhochschule Erfurt (FHE); Bundesamt für Kartographie und Geodäsie (BKG) |
| 49 | 6.1 | Organisation Hackathon |  | 62d | 2022-03-01 | 2022-05-25 |  |  |
| 50 | 6.2 | Hackathon Durchführung |  | 2d | 2022-05-26 | 2022-05-27 | 49 |  |

Notes:
- 34: Sinnvolle Testszenarios für die Anwendungsfälle bestimmen
- 39: Werkzeuge: / - INSPIRE Validator / - Testsuite
- 40: Benutzung von GIS um Anwendungen/Daten/Dienste zu testen.
- 41: Relative Qualität des erreichten Zustands zu vorformulierten Zielen.
- 44: laut Rudolf
- 48: Wenn ein Hackathon bereits Mitte 2021 gewünscht/möglich ist uU Absprache mit F.Würriehausen zwecks Synergien. / 1. Projektleitung / 2. Falk
- 49: Hackathon soll zum Abschluss des Projektes stattfinden. / Verwendet werden im Optimalfall, Daten und Dienste die durch das envVisio-GI Projekt erarbeitet werden konnten.
